# Projekt_jo_02_03

Schedule from MS Project, 2008-10-15 to 2008-12-01, status date 2008-10-31, scheduled back from the finish, costs in Ft, A marks actual dates.
iqjb

## Calendars

- Szabványos: Mon-Fri 08:00-12:00, 13:00-17:00; Sat-Sun off.

## Resources

| Resource | Unit | Rate |
| --- | --- | --- |
| Á hálózatépítő 1 |  | 1500 |
| Á műszaki informatikus 1 |  | 1500 |
| Á adminisztrátor 1 |  | 1000 |
| Kovács Anita |  | 6000 |
| Kiss Attila |  | 10000 |
| Nagy Annamária |  |  |
| Paál Anikó |  |  |
| Kiss Anett |  | 800 |
| Rétlaki Géza |  | 1400 |
| Mároki Teréz |  | 1400 |
| Mosolygó Ferenc |  | 1600 |
| Téglás Csaba |  | 1200 |
| Podorek Paula |  | 800 |
| Tiefenghalter Eszter |  | 1200 |
| Szakócza István |  | 1700 |
| Késmárki Lilla |  | 1500 |
| Á hálózatépítő 2 |  | 1500 |
| Á műszaki informatikus 2 |  | 1500 |
| Á adminisztrátor 2 |  | 1000 |
| Á adminisztrátor 3 |  | 1000 |
| Á adminisztrátor 4 |  | 1000 |
| Számítógép beszerzési költségek | eFt | 1000 |
| Hálózatépítés költségei | eFt | 1000 |
| Egyéb költségek | eFt | 1000 |
| Szoftverköltségek | eFt | 1000 |
| Á programozó 1 |  | 5000 |
| Á programozó 2 |  | 5000 |
| Á műszaki informatikus 3 |  | 1500 |

## Schedule

| ID | WBS | Task | Type | Duration | Start | Finish | Predecessors | Complete | Remaining | Baseline start | Baseline finish | Baseline duration | Total slack | Constraint | Resources | Work | Actual work | Cost | Baseline cost | Actual cost | Text29 | nap, óra |
| --- | --- | --- | --- | --- | --- | --- | --- | --- | --- | --- | --- | --- | --- | --- | --- | --- | --- | --- | --- | --- | --- | --- |
| 1 | 1 | **előkészítés** |  | 33.5d? | 2008-10-15 A | 2008-12-01 |  | 9% | 30.55d? | 2008-10-15 | 2008-12-01 | 33.5d? | 0d | as late as possible |  | 940h | 64h | 181,887,600 | 181,887,600 | 96,000 | 480 | 33 n, 4 ó |
| 2 | 1.1 | A vállalat hardverkiépítettségének vizsgálata |  | 4d | 2008-10-15 A | 2008-10-21 A |  | 100% |  | 2008-10-15 | 2008-10-21 | 4d |  |  | Á hálózatépítő 2; Á műszaki informatikus 3 | 64h | 64h | 96,000 | 96,000 | 96,000 | 480 | 4 n |
| 3 | 1.2 | igények felmérése |  | 10d | 2008-10-15 | 2008-10-29 | 2SS |  |  | 2008-10-15 | 2008-10-29 | 10d | 0d | start no later than 2008-10-17 | Á adminisztrátor 1; Á adminisztrátor 2; Á adminisztrátor 3; Téglás Csaba | 320h |  | 336,000 | 336,000 |  | 480 | 10 n |
| 4 | 1.3 | igények felmérése befejezés |  | 1d? | 2008-10-28 | 2008-10-29 | 3FF |  |  | 2008-10-28 | 2008-10-29 | 1d? | 0d |  |  |  |  |  |  |  | 480 | 1 n |
| 5 | 1.4 | igények kiértékelése |  | 4d | 2008-10-28 | 2008-11-03 | 3SS+4d, 4FF+3d |  |  | 2008-10-28 | 2008-11-03 | 4d | 0d |  | Á adminisztrátor 4; Téglás Csaba; Á műszaki informatikus 2 | 96h |  | 118,400 | 118,400 |  | 480 | 4 n |
| 6 | 1.5 | A számítógépes munkavégzés analizálása |  | 3d | 2008-11-03 | 2008-11-06 | 5 |  |  | 2008-11-03 | 2008-11-06 | 3d | 1d |  | Téglás Csaba | 24h |  | 28,800 | 28,800 |  | 480 | 3 n |
| 7 | 1.6 | Az operációsrendszer és a felhasználói programok tesztelése |  | 4d | 2008-11-03 | 2008-11-07 | 5 |  |  | 2008-11-03 | 2008-11-07 | 4d | 0d |  | Á műszaki informatikus 2 | 32h |  | 48,000 | 48,000 |  | 480 | 4 n |
| 8 | 1.7 | Legális hackelés engedélyezése | milestone | 0d | 2008-10-15 | 2008-11-07 |  |  |  | 2008-10-15 | 2008-11-07 | 0d | 0d |  |  |  |  |  |  |  | 480 | --mérföldkő-- |
| 9 | 1.8 | Legális hackelés |  | 5d | 2008-11-07 | 2008-11-14 | 7, 6, 8 |  |  | 2008-11-07 | 2008-11-14 | 5d | 0d |  | Á programozó 1; Á programozó 2; Téglás Csaba; Szoftverköltségek [180000 eFt] | 120h |  | 180,448,000 | 180,448,000 |  | 480 | 5 n |
| 10 | 1.9 | - |  | 2d | 2008-11-14 | 2008-11-18 | 9 |  |  | 2008-11-14 | 2008-11-18 | 2d | 0d |  |  |  |  |  |  |  | 480 | 2 n |
| 11 | 1.10 | Adatok kiértékelése |  | 3d | 2008-11-13 | 2008-11-18 | 9SS+2d, 10FF |  |  | 2008-11-13 | 2008-11-18 | 3d | 0d |  | Á programozó 1; Á adminisztrátor 1; Á adminisztrátor 2 | 72h |  | 168,000 | 168,000 |  | 480 | 3 n |
| 12 | 1.11 | megoldási lehetőségek kidolgozása |  | 3d | 2008-11-18 | 2008-11-21 | 11 |  |  | 2008-11-18 | 2008-11-21 | 3d | 0d |  | Á adminisztrátor 1; Á hálózatépítő 1; Téglás Csaba; Á programozó 1 | 96h |  | 208,800 | 208,800 |  | 480 | 3 n |
| 13 | 1.12 | javaslatok dokumentum kész | milestone | 0d | 2008-11-21 | 2008-12-01 | 12 |  |  | 2008-11-21 | 2008-12-01 | 0d | 0d |  |  |  |  |  |  |  | 480 | --mérföldkő-- |
| 14 | 1.13 | megoldási lehetőségek ismertetése |  | 4h | 2008-11-21 | 2008-11-21 | 12 |  |  | 2008-11-21 | 2008-11-21 | 4h | 0d |  | Kovács Anita; Paál Anikó; Kiss Attila; Nagy Annamária; Szakócza István | 20h |  | 70,800 | 70,800 |  | 480 | 4 ó |
| 15 | 1.14 | döntés a megvalósítandó lehetőségről | milestone | 0d | 2008-11-21 | 2008-11-24 | 14 |  |  | 2008-11-21 | 2008-11-24 | 0d | 0d |  | Nagy Annamária |  |  |  |  |  | 480 | --mérföldkő-- |
| 16 | 1.15 | részletes terv kidolgozása |  | 6d | 2008-11-24 | 2008-12-01 | 15 |  |  | 2008-11-24 | 2008-12-01 | 6d | 0d |  | Kovács Anita; Szakócza István [50%]; Á hálózatépítő 1 [50%] | 96h |  | 364,800 | 364,800 |  | 480 | 6 n |
| 17 | 1.16 | terv elfogadtatása | milestone | 0d | 2008-12-01 | 2008-12-01 | 16 |  |  | 2008-12-01 | 2008-12-01 | 0d | 0d |  | Kiss Attila; Nagy Annamária |  |  |  |  |  | 480 | --mérföldkő-- |
