# Projekt_jo_02_03

Schedule from MS Project, 2008-12-16 to 2009-02-02, costs in Ft.
iqjb

## Calendars

- Szabványos: Mon-Fri 08:00-12:00, 13:00-17:00; Sat-Sun off.

## Resources

| Resource | Unit | Rate |
| --- | --- | --- |
| Á hálózatépítő 1 |  | 1500 |
| Á műszaki informatikus 1 |  | 1500 |
| Á adminisztrátor 1 |  | 1000 |
| Kovács Anita |  | 6000 |
| Kiss Attila |  | 10000 |
| Nagy Annamária |  | 1200 |
| Paál Anikó |  | 1300 |
| Kőbán Péter |  | 4200 |
| Rétlaki Géza |  | 4400 |
| Mároki Teréz |  | 1400 |
| Mosolygó Ferenc |  | 4100 |
| Podorek Paula |  | 4100 |
| Tiefenghalter Eszter |  | 1200 |
| Szakócza István |  | 3900 |
| Késmárki Lilla |  | 4000 |
| Á hálózatépítő 2 |  | 1500 |
| Á műszaki informatikus 2 |  | 1500 |
| Á adminisztrátor 2 |  | 1000 |
| Á műszaki informatikus 3 |  | 1500 |
| Á adminisztrátor 3 |  | 1000 |
| Á adminisztrátor 4 |  | 1000 |
| Számítógép beszerzési költségek | eFt | 1000 |
| Hálózatépítés költségei | eFt | 1000 |
| Szoftverköltségek | eFt | 1000 |
| Á_projektszponzor |  | 8000 |
| Á oktató 1 |  | 4000 |
| Á oktató 2 |  | 4000 |
| Á oktató 3 |  | 4000 |
| Á műszaki informatikus 4 |  | 1500 |
| Kő Pál |  | 1200 |
| Kiss Irén |  | 1200 |
| Nagy Armand |  | 1200 |
| Beke Botond |  | 1200 |
| Kőváry Laura |  | 1200 |
| Kőpataki Tihamér |  | 2100 |
| Baumgartner Karina |  | 5000 |
| Mathiugasz Gitisz |  | 6000 |
| Oktatók |  |  |
| Műszaki szakemberek |  |  |
| Telepítési csoport |  |  |
| Á_projektmenedzser |  | 6000 |
| Á megbízó koordinátor 1 |  | 2500 |
| Á megbízó koordinátor 2 |  | 2500 |
| Kiss Edit |  | 7000 |
| Molnár Noémi |  | 7000 |
| Nyári Éva |  | 2500 |
| Botond Építő Kft. |  |  |
| Megbízási díj | eFt | 1000 |
| Á_rendszergazda 1 |  | 3000 |
| Á_rendszergazda 2 |  | 3000 |
| Á_rendszergazda 3 |  | 3000 |
| Á_rendszergazda 4 |  | 3000 |
| Megbízási díj | eFt | 1000 |
| Fuksz Éva |  | 2000 |
| Á villamosmérnök 1 |  | 4000 |
| Á villamosmérnök 2 |  | 4000 |
| Á villamosmérnök 3 |  | 4000 |
| Á programozó 1 |  | 4500 |
| Á programozó 2 |  | 4500 |
| Á programozó 3 |  | 4500 |
| Á programozó 4 |  | 4500 |
| Téglás Csaba |  | 4000 |

## Schedule

| ID | WBS | Task | Type | Duration | Start | Finish | Predecessors | Total slack | Free slack | Resources | Work | Cost | Text29 | Text30 | Text1 |
| --- | --- | --- | --- | --- | --- | --- | --- | --- | --- | --- | --- | --- | --- | --- | --- |
| 1 | S2-2008-TVS | **tervezés** |  | 4.5d | 2008-12-16 | 2008-12-22 |  | 0d |  |  | 132h | 552,000 | 480 | 4 n, 4 ó |  |
| 2 | S2-2008-TVS.tvmb | **megbeszélés** |  | 0.38d | 2008-12-16 | 2008-12-16 |  | 34.42d |  |  |  |  |  | 3 ó |  |
| 3 | S2-2008-TVS.tvmb.pjmb01 | megbeszélés 1 |  | 1h | 2008-12-16 | 2008-12-16 |  | 34.42d | 0d |  |  |  | 480 | 1 ó |  |
| 4 | S2-2008-TVS.tvmb.pjmb02 | megbeszélés 2 |  | 1h | 2008-12-16 | 2008-12-16 | 3 | 34.42d | 0d |  |  |  | 480 | 1 ó |  |
| 5 | S2-2008-TVS.tvmb.pjmb03 | megbeszélés 3 |  | 1h | 2008-12-16 | 2008-12-16 | 4 | 34.42d |  |  |  |  | 480 | 1 ó |  |
| 6 | S2-2008-TVS.szft | **szoftver tervezése** |  | 3d | 2008-12-16 | 2008-12-18 |  | 0d |  |  | 52h | 228,000 | 480 | 3 n |  |
| 7 | S2-2008-TVS.szft.tvpará | tervezési paraméterek átvétele |  | 0.5d | 2008-12-16 | 2008-12-16 |  | 0d |  | Á programozó 1; Á programozó 2; Á programozó 3; Á programozó 4 | 16h | 72,000 | 480 | 4 ó |  |
| 8 | S2-2008-TVS.szft.tvparp | tervezési paraméterek pontosítása |  | 1d | 2008-12-16 | 2008-12-17 | 7 | 4.3d | 0d | Á programozó 1 [150%]; Á programozó 3 [150%] | 24h | 108,000 | 480 | 1 n |  |
| 9 | S2-2008-TVS.szft.tsparm | tesztelési paraméterek meghatározása |  | 1d | 2008-12-17 | 2008-12-18 | 8 | 4.3d | 0d | Á villamosmérnök 1 | 8h | 32,000 | 480 | 1 n |  |
| 10 | S2-2008-TVS.szft.hrparm | hardvertervezési paraméterek meghatározása |  | 0.5d | 2008-12-18 | 2008-12-18 | 9 | 31.8d |  | Á villamosmérnök 1 | 4h | 16,000 | 480 | 4 ó |  |
| 11 | S2-2008-TVS.hrdt | **hardver terezése, próbapéldány készítése** |  | 4.5d | 2008-12-16 | 2008-12-22 |  | 0d |  |  | 80h | 324,000 | 480 | 4 n, 4 ó |  |
| 12 | S2-2008-TVS.hrdt.tvpará | tervezési paraméterek átvétele |  | 0.5d | 2008-12-16 | 2008-12-16 | 7SS | 0d |  | Á villamosmérnök 1; Á villamosmérnök 2 | 8h | 32,000 | 480 | 4 ó |  |
| 13 | S2-2008-TVS.hrdt.tvparp | tervezési paraméterek pontosítása |  | 1d | 2008-12-16 | 2008-12-17 | 12 | 3.3d | 0d | Á villamosmérnök 1; Á villamosmérnök 2; Á programozó 3 | 24h | 100,000 | 480 | 1 n |  |
| 14 | S2-2008-TVS.hrdt.*hrdtv | hardver tervezése |  | 3d | 2008-12-17 | 2008-12-22 | 13 | 3.3d | 0d | Á villamosmérnök 1; Á villamosmérnök 2 | 48h | 192,000 | 480 | 3 n |  |
| 15 | S2-2008-TVS.hrdt.hrdtvk | hardvertervezés kész | milestone | 0d | 2008-12-22 | 2008-12-22 | 14 | 3.3d |  |  |  |  | 480 | --mérföldkő-- |  |
| 16 | S2-2008-KÓD | **kódolás** |  | 7.8d | 2008-12-16 | 2008-12-25 |  | 0d |  |  | 192h | 864,000 | 480 | 7 n, 6,4 ó |  |
| 17 | S2-2008-KÓD.amod | **1. modul** |  | 6d | 2008-12-16 | 2008-12-23 |  | 0d |  |  | 96h | 432,000 | 480 | 6 n |  |
| 18 | S2-2008-KÓD.amod.*kódol | kódolás |  | 6d | 2008-12-16 | 2008-12-23 | 12SS | 0d |  | Á programozó 1; Á programozó 2 | 96h | 432,000 | 480 | 6 n |  |
| 19 | S2-2008-KÓD.fmod | **főmodul** |  | 6d | 2008-12-17 | 2008-12-25 |  | 0d |  |  | 96h | 432,000 | 480 | 6 n |  |
| 20 | S2-2008-KÓD.fmod.*kódol | kódolás |  | 6d | 2008-12-17 | 2008-12-25 | 18SS+3% | 0d |  | Á programozó 3; Á programozó 4 | 96h | 432,000 | 480 | 6 n |  |
| 21 | S2-2008-KÓD.kódk | kódolás kész | milestone | 0d | 2008-12-25 | 2008-12-25 | 18, 20 | 27d |  |  |  |  | 480 | --mérföldkő-- |  |
| 22 | S2-2008-TST | **tesztelés** |  | 34.8d | 2008-12-16 | 2009-02-02 |  | 0d |  |  | 376h | 1,584,000 |  | 34 n, 6,4 ó |  |
| 23 | S2-2008-TST.szft | **szoftvertesztelés** |  | 20.3d | 2008-12-18 | 2009-01-15 |  | 4.3d |  |  | 80h | 352,000 |  | 20 n, 2,4 ó |  |
| 24 | S2-2008-TST.szft.tszprá | tesztelési paraméterek átvétele |  | 0.5d | 2008-12-18 | 2008-12-18 | 9, 20SS | 4.3d | 0d | Á programozó 1; Á programozó 2; Á programozó 3; Á villamosmérnök 1 | 16h | 70,000 | 480 | 4 ó |  |
| 25 | S2-2008-TST.szft.tszgin | tesztgép inicializálása |  | 0.5d | 2008-12-19 | 2008-12-19 | 24 | 4.3d |  | Á programozó 1; Á villamosmérnök 1 | 8h | 34,000 | 480 | 4 ó |  |
| 26 | S2-2008-TST.szft.**tszt | tesztelés |  | 13d | 2008-12-25 | 2009-01-13 | 25, 18, 20, 15 | 0d |  |  |  |  | 480 | 13 n | ts |
| 27 | S2-2008-TST.szft.kiértT | tesztelés kiértékelése |  | 2d | 2009-01-13 | 2009-01-15 | 26 | 12d | 0d | Á programozó 1; Á programozó 2; Á programozó 3; Á villamosmérnök 1 [50%] | 56h | 248,000 | 480 | 2 n |  |
| 28 | S2-2008-TST.szft.*szttk | szoftvertesztelés kész | milestone | 0d | 2009-01-15 | 2009-01-15 | 27 | 12d |  |  |  |  | 480 | --mérföldkő-- |  |

| ID | WBS | Task | Type | Duration | Start | Finish | Predecessors | Total slack | Resources | Work | Cost | Text30 | Text29 | Text1 |
| --- | --- | --- | --- | --- | --- | --- | --- | --- | --- | --- | --- | --- | --- | --- |
| 29 | S2-2008-TST.hrdt | **fizikai tesztelés** |  | 34.8d | 2008-12-16 | 2009-02-02 |  | 0d |  | 296h | 1,232,000 | 34 n, 6,4 ó |  |  |
| 30 | S2-2008-TST.hrdt.*irátt | tesztelési irányelvek áttekintése |  | 1d | 2008-12-16 | 2008-12-16 |  | 18.8d | Á programozó 2; Á villamosmérnök 1; Á villamosmérnök 2; Á villamosmérnök 3 | 32h | 132,000 | 1 n | 480 |  |
| 31 | S2-2008-TST.hrdt.hrszfi | teszthardver és szoftver inicializálása |  | 1d | 2009-01-12 | 2009-01-13 | 30, 26FF | 0d | Á programozó 2; Á villamosmérnök 1 | 16h | 68,000 | 1 n | 480 |  |
| 32 | S2-2008-TST.hrdt.tmérőp | mérőpados tesztelés |  | 10d | 2009-01-13 | 2009-01-27 | 31 | 0d | Á programozó 1; Á villamosmérnök 1; Á villamosmérnök 2 | 240h | 1,000,000 | 10 n | 480 | ts |
| 33 | S2-2008-TST.hrdt.beépkj | beépítés a kísérleti járműbe |  | 1d | 2009-01-23 | 2009-01-26 | 32FS-2d | 0d | Á villamosmérnök 3 | 8h | 32,000 | 1 n | 480 |  |
| 34 | S2-2008-TST.hrdt.beptst | beépítéses tesztelés |  | 3d | 2009-01-26 | 2009-01-29 | 32FF, 33 | 0d |  |  |  | 3 n | 480 | ts |
| 35 | S2-2008-TST.hrdt.terfld | tesztelési eredmények feldolgozása |  | 2d | 2009-01-29 | 2009-02-02 | 32, 34 | 0d |  |  |  | 2 n | 480 |  |
| 36 | S2-2008-TST.hrdt.*hrdtk | fizikai tesztelés kész | milestone | 0d | 2009-02-02 | 2009-02-02 | 35 | 0d |  |  |  | --mérföldkő-- | 480 |  |
| 37 | S2-2008-TST.hrdt.****** | tesztelések kész | milestone | 0d | 2009-02-02 | 2009-02-02 | 36, 28 | 0d |  |  |  | --mérföldkő-- | 480 |  |
