# Projekt_jo_02_03

Schedule from MS Project, 2008-12-25 to 2009-01-15, costs in Ft.
iqjb

## Calendars

- Szabványos: Mon-Fri 08:00-12:00, 13:00-17:00; Sat-Sun off.

## Resources

| Resource | Unit | Rate |
| --- | --- | --- |
| Á hálózatépítő 1 |  | 1500 |
| Á műszaki informatikus 1 |  | 1500 |
| Á adminisztrátor 1 |  | 1000 |
| Kovács Anita |  | 6000 |
| Kiss Attila |  | 10000 |
| Nagy Annamária |  | 1200 |
| Paál Anikó |  | 1300 |
| Kőbán Péter |  | 4200 |
| Rétlaki Géza |  | 4400 |
| Mároki Teréz |  | 1400 |
| Mosolygó Ferenc |  | 4100 |
| Téglás Csaba |  | 4000 |
| Podorek Paula |  | 4100 |
| Tiefenghalter Eszter |  | 1200 |
| Szakócza István |  | 3900 |
| Késmárki Lilla |  | 4000 |
| Á hálózatépítő 2 |  | 1500 |
| Á műszaki informatikus 2 |  | 1500 |
| Á adminisztrátor 2 |  | 1000 |
| Á műszaki informatikus 3 |  | 1500 |
| Á adminisztrátor 3 |  | 1000 |
| Á adminisztrátor 4 |  | 1000 |
| Számítógép beszerzési költségek | eFt | 1000 |
| Hálózatépítés költségei | eFt | 1000 |
| Szoftverköltségek | eFt | 1000 |
| Á programozó 3 |  | 4500 |
| Á programozó 4 |  | 4500 |
| Á_projektszponzor |  | 8000 |
| Á oktató 1 |  | 4000 |
| Á oktató 2 |  | 4000 |
| Á oktató 3 |  | 4000 |
| Á műszaki informatikus 4 |  | 1500 |
| Kő Pál |  | 1200 |
| Kiss Irén |  | 1200 |
| Nagy Armand |  | 1200 |
| Beke Botond |  | 1200 |
| Kőváry Laura |  | 1200 |
| Kőpataki Tihamér |  | 2100 |
| Baumgartner Karina |  | 5000 |
| Mathiugasz Gitisz |  | 6000 |
| Oktatók |  |  |
| Műszaki szakemberek |  |  |
| Telepítési csoport |  |  |
| Á programozó 1 |  | 4500 |
| Á programozó 2 |  | 4500 |
| Á_projektmenedzser |  | 6000 |
| Á megbízó koordinátor 1 |  | 2500 |
| Á megbízó koordinátor 2 |  | 2500 |
| Kiss Edit |  | 7000 |
| Molnár Noémi |  | 7000 |
| Nyári Éva |  | 2500 |
| Botond Építő Kft. |  |  |
| Megbízási díj | eFt | 1000 |
| Á_rendszergazda 1 |  | 3000 |
| Á_rendszergazda 2 |  | 3000 |
| Á_rendszergazda 3 |  | 3000 |
| Á_rendszergazda 4 |  | 3000 |
| Megbízási díj | eFt | 1000 |
| Fuksz Éva |  | 2000 |
| Egyéb költségek | eFt | 1000 |
| Á_villamosmérnök 1 |  |  |
| Á_villamosmérnök 2 |  |  |
| Á_villamosmérnök 3 |  |  |

## Schedule

| ID | WBS | Task | Type | Duration | Start | Finish | Predecessors | Total slack | Free slack | Resources | Work | Cost | Text30 | Text29 | Text1 |
| --- | --- | --- | --- | --- | --- | --- | --- | --- | --- | --- | --- | --- | --- | --- | --- |
| 1 | S2-2008-TST | **tesztelés** |  | 2d | 2008-12-25 | 2008-12-26 |  | 14d |  |  | 80h | 288,000 | 2 n |  |  |
| 2 | S2-2008-TST.szof | **szoftvertesztelés** |  | 2d | 2008-12-25 | 2008-12-26 |  | 14d |  |  | 80h | 288,000 | 2 n |  |  |
| 3 | S2-2008-TST.szof.****** | tesztelési paraméterek átvétele |  | 0.5d | 2008-12-25 | 2008-12-25 |  | 15d | 0d | Á programozó 1; Á programozó 2; Á programozó 3; Á_villamosmérnök 1 | 16h | 54,000 | 4 ó | 480 |  |
| 4 | 1.1.2 | tesztgép inicializálása |  | 0.5d | 2008-12-25 | 2008-12-25 | 3 | 15d |  | Á programozó 1; Á_villamosmérnök 1 | 8h | 18,000 | 4 ó | 480 |  |
| 5 | S2-2008-TST.szof.kiértT | tesztelés kiértékelése |  | 2d | 2008-12-25 | 2008-12-26 |  | 14d |  | Á programozó 1; Á programozó 2; Á programozó 3; Á_villamosmérnök 1 [50%] | 56h | 216,000 | 2 n | 480 |  |
| 6 | S2-2008-TSU | **fizikai tesztelés** |  | 16d | 2008-12-25 | 2009-01-15 |  | 0d |  |  | 296h | 432,000 | 16 n |  |  |
| 7 | S2-2008-TSU.aaaa | tesztelési irányelvek áttekintése |  | 1d | 2008-12-25 | 2008-12-25 |  | 0d |  | Á programozó 2; Á_villamosmérnök 1; Á_villamosmérnök 2; Á_villamosmérnök 3 | 32h | 36,000 | 1 n | 480 |  |
| 8 | S2-2008-TSU.aaab | teszthardver és szoftver inicializálása |  | 1d | 2008-12-26 | 2008-12-26 | 7 | 0d |  | Á programozó 2; Á_villamosmérnök 1 | 16h | 36,000 | 1 n | 480 |  |
| 9 | S2-2008-TSU.aaac | mérőpados tesztelés |  | 10d | 2008-12-29 | 2009-01-09 | 8 | 0d |  | Á programozó 1; Á_villamosmérnök 1; Á_villamosmérnök 2 | 240h | 360,000 | 10 n | 480 | ts |
| 10 | S2-2008-TSU.aaad | beépítés a kísérleti járműbe |  | 1d | 2009-01-08 | 2009-01-08 | 9FS-2d | 0d |  | Á_villamosmérnök 3 | 8h |  | 1 n | 480 |  |
| 11 | S2-2008-TSU.aaae | beépítéses tesztelés |  | 3d | 2009-01-09 | 2009-01-13 | 9FF, 10 | 0d |  |  |  |  | 3 n | 480 | ts |
| 12 | S2-2008-TSU.aaaf | tesztelési eredmények feldolgozása |  | 2d | 2009-01-14 | 2009-01-15 | 9, 11 | 0d |  |  |  |  | 2 n | 480 |  |
| 13 | S2-2008-TSU.aaag | fizikai tesztelés kész | milestone | 0d | 2009-01-15 | 2009-01-15 | 12 | 0d |  |  |  |  | --mérföldkő-- | 480 |  |
| 14 | S2-2008-TSU.szoi | tesztelések kész | milestone | 0d | 2009-01-15 | 2009-01-15 | 13 | 0d |  |  |  |  | --mérföldkő-- | 480 |  |
