# Projekt_jo_02_03

Schedule from MS Project, 2009-01-13 to 2009-04-30, costs in Ft.
iqjb

## Calendars

- Szabványos: Mon-Fri 08:00-12:00, 13:00-17:00; Sat-Sun off.

## Resources

| Resource | Rate |
| --- | --- |
| Á programozó 1 | 4500 |
| Á programozó 2 | 4500 |
| Á programozó 3 | 4500 |
| Á programozó 4 | 4500 |
| Á programozó 5 | 4500 |
| Á programozó 6 | 4500 |
| Kiss Anett | 3500 |
| Nagy Lajos | 4400 |
| Rizs Ottó | 5000 |
| Nagy Anita | 4600 |
| Kurtán Lajos | 2000 |
| Hermencz Béla | 4500 |
| Á hálózatépítő 1 | 2500 |
| Á hálózatépítő 2 | 2500 |
| Á hálózatépítő 3 | 2500 |
| Á hálózatépítő 4 | 2500 |
| Zorek Anna | 2400 |
| Tomory Pál | 2800 |
| Zách Felicián | 2300 |
| Kincses Éva | 2500 |
| Á adminisztrátor 1 | 2000 |
| Á adminisztrátor 2 | 2000 |
| Á adminisztrátor 3 | 2000 |
| Á adminisztrátor 4 | 2000 |
| Kiss Irén | 1000 |
| Braun Éva | 2000 |
| Lakner Pál | 1600 |
| Polnauer Erika | 2000 |
| Á rendszergazda 1 | 3500 |
| Á rendszergazda 2 | 3500 |
| Ney Károly | 3500 |
| Kochen Zoltán | 3700 |
| Ktg. EUR-ban | 283 |
| Ktg. USD-ban | 210 |
| Á villamosmérnök 1 | 4500 |
| Á villamosmérnök 2 | 4500 |
| Á villamosmérnök 3 | 4500 |
| Simonyi Károly | 5200 |
| Csizek Éva | 4200 |
| Pálfalai Péter | 3800 |
| Godrobán Emese | 2000 |
| Á adatbázistervező 1 | 4500 |
| Á adatbázistervező 2 | 4500 |
| Pocsonkai Pál | 4500 |
| Á műszaki informatikus 1 | 2000 |
| Á műszaki informatikus 2 | 2000 |
| Beke István | 2000 |
| Ney Katalin | 1900 |
| Á szponzor | 10000 |

## Schedule

| ID | WBS | Task | Type | Duration | Start | Finish | Predecessors | Total slack | Free slack | Resources | Work | Cost | Text29 | Text30 |
| --- | --- | --- | --- | --- | --- | --- | --- | --- | --- | --- | --- | --- | --- | --- |
| 1 | S2-2008-TSU | **Előtervezés** |  | 5.5d | 2009-01-13 | 2009-01-20 |  | 0d |  |  | 188h | 704,000 | 480 | 5 n, 4 ó |
| 2 | 1.1 | indító megbeszélés |  | 4h | 2009-01-13 | 2009-01-13 |  | 72.5d | 0d | Á adatbázistervező 1; Á adatbázistervező 2; Á adminisztrátor 1; Á hálózatépítő 1; Á műszaki informatikus 1; Á műszaki informatikus 2; Á programozó 1; Á programozó 2; Á programozó 3; Á rendszergazda 1; Á villamosmérnök 1 | 44h | 156,000 | 480 | 4 ó |
| 3 | S2-2008-TSU.aaaa | paraméterek meghatározása |  | 1d | 2009-01-13 | 2009-01-14 | 2 | 72.5d | 0d | Á műszaki informatikus 1; Á adatbázistervező 1; Á programozó 1 | 24h | 88,000 | 480 | 1 n |
| 4 | S2-2008-TSU.aaab | igényfelmérő, szintfelmérő kérdések összeállítása |  | 2d | 2009-01-14 | 2009-01-16 | 3 | 72.5d | 0d | Á műszaki informatikus 1; Á műszaki informatikus 2 | 32h | 64,000 | 480 | 2 n |
| 5 | 1.4 | igényfelmérő, szintfelmérő szoftver inicializálása |  | 2d | 2009-01-16 | 2009-01-20 | 4 | 72.5d |  | Á programozó 1 | 16h | 72,000 | 480 | 2 n |
| 6 | 1.5 | javaslatok kidolgozása |  | 2d | 2009-01-13 | 2009-01-14 |  | 76d |  | Á adatbázistervező 1; Á programozó 1; Á villamosmérnök 1 | 48h | 216,000 | 480 | 2 n |
| 7 | 1.6 | tervezési paraméterek meghatározása |  | 1d | 2009-01-13 | 2009-01-13 |  | 0d |  | Á adatbázistervező 1; Á programozó 1; Á villamosmérnök 1 | 24h | 108,000 | 480 | 1 n |
| 8 | S2-2008-TSW | **Tervezés** |  | 13.5d | 2009-01-13 | 2009-01-30 |  | 1d |  |  | 388h | 1,692,000 | 480 | 13 n, 4 ó |
| 9 | S2-2008-TSW.aaaa | tervezési paraméterek átvétele |  | 4h | 2009-01-14 | 2009-01-14 | 7 | 0d |  | Á adatbázistervező 1; Á adatbázistervező 2; Á programozó 1; Á programozó 2; Á programozó 3; Á villamosmérnök 1 | 24h | 108,000 | 480 | 4 ó |
| 10 | S2-2008-TSW.aaae | adatbáisterv elkészítése |  | 6d | 2009-01-14 | 2009-01-22 | 9 | 0d |  | Á adatbázistervező 1; Á adatbázistervező 2; Á műszaki informatikus 1 [25%] | 108h | 456,000 | 480 | 6 n |
| 11 | S2-2008-TSW.aaaf | adatbázisterv kész | milestone | 0d | 2009-01-22 | 2009-01-22 | 10 | 7d | 6d |  |  |  | 480 | --mérföldkő-- |
| 12 | S2-2008-TSW.aaab | szükséges szoftverek beszerzése |  | 1d | 2009-01-14 | 2009-01-15 | 9 | 1d | 0d | Á műszaki informatikus 1 | 8h | 16,000 | 480 | 1 n |
| 13 | S2-2008-TSW.aaac | szoftverek inicializálása |  | 1d | 2009-01-15 | 2009-01-16 | 12 | 1d | 0d | Á programozó 1 [50%]; Á rendszergazda 1 [50%] | 8h | 32,000 | 480 | 1 n |
| 14 | S2-2008-TSW.aaad | programterv elkészítése |  | 10d | 2009-01-16 | 2009-01-30 | 9, 13, 10FF+2.5% | 1d | 0d | Á programozó 1; Á programozó 2; Á programozó 3 | 240h | 1,080,000 | 480 | 10 n |
| 15 | S2-2008-TSW.aaah | terv kész | milestone | 0h | 2009-01-30 | 2009-01-30 | 11, 14 | 1d | 0d |  |  |  | 480 | --mérföldkő-- |
| 16 | S2-2008-TSW.aaaj | megrendelés visszaigazolása | milestone | 0d | 2009-01-13 | 2009-01-13 |  | 14.5d | 13.5d |  |  |  | 480 | --mérföldkő-- |
| 17 | S2-2008-TSY | **kódolás** |  | 27d | 2009-01-22 | 2009-03-02 |  | 0d |  |  | 304h | 1,368,000 | 480 | 27 n |
| 18 | S2-2008-TSY.aaad | programterv átvétele | milestone | 0h | 2009-01-30 | 2009-01-30 | 15, 16 | 1d | 0d |  |  |  | 480 | --mérföldkő-- |
| 19 | S2-2008-TSY.aaae | adatbázis felállítása |  | 2d | 2009-01-22 | 2009-01-26 | 10 | 0d |  | Á adatbázistervező 1; Á adatbázistervező 2 | 32h | 144,000 | 480 | 2 n |
| 20 | S2-2008-TSY.aaaa | 1. modul kódolása |  | 8d | 2009-01-30 | 2009-02-11 | 19, 18 | 3d | 0d | Á programozó 1 | 64h | 288,000 | 480 | 8 n |
| 21 | S2-2008-TSY.aaab | 2. modul kódolása |  | 10d | 2009-02-02 | 2009-02-16 | 18, 19, 28 | 0d |  | Á programozó 2 | 80h | 360,000 | 480 | 10 n |
| 22 | S2-2008-TSY.aaac | 3. modul kódolása |  | 6d | 2009-01-30 | 2009-02-09 | 18, 19 | 5d | 0d | Á programozó 3 | 48h | 216,000 | 480 | 6 n |
| 23 | S2-2008-TSY.aaaf | főmodul kódolása |  | 10d | 2009-02-16 | 2009-03-02 | 20, 21, 22 | 0d |  | Á programozó 1 | 80h | 360,000 | 480 | 10 n |
| 24 | S2-2008-TSY.aaag | kódolás kész | milestone | 0d | 2009-03-02 | 2009-03-02 | 23 | 0d |  |  |  |  | 480 | --mérföldkő-- |

| ID | WBS | Task | Type | Duration | Start | Finish | Predecessors | Total slack | Free slack | Resources | Work | Cost | Text29 | Text30 |
| --- | --- | --- | --- | --- | --- | --- | --- | --- | --- | --- | --- | --- | --- | --- |
| 25 | S2-2008-TTA | **tesztelés** |  | 35d | 2009-01-26 | 2009-03-16 |  | 0d |  |  | 1136h | 2,312,000 | 480 | 35 n |
| 26 | S2-2008-TTA.aaal | adatbázis feltöltése tesztadatokkal |  | 2d | 2009-01-26 | 2009-01-28 | 19 | 0d |  | Á műszaki informatikus 1; Á műszaki informatikus 2 | 32h | 64,000 | 480 | 2 n |
| 27 | S2-2008-TTA.aaam | adatbátis tesztelése |  | 2d | 2009-01-28 | 2009-01-30 | 26 | 0d |  | Á műszaki informatikus 1; Á műszaki informatikus 2; Á adatbázistervező 1 [50%] | 40h | 100,000 | 480 | 2 n |
| 28 | S2-2008-TTA.aaan | javaslatok kidolgozása |  | 1d | 2009-01-30 | 2009-02-02 | 27 | 0d |  | Á adatbázistervező 1 | 8h | 36,000 | 480 | 1 n |
| 29 | S2-2008-TTA.aaai | 1. modul tesztelése |  | 10d | 2009-02-11 | 2009-02-25 | 20 | 3d | 0d | Á adminisztrátor 1; Á adminisztrátor 2; Á műszaki informatikus 1 | 240h | 480,000 | 480 | 10 n |
| 30 | S2-2008-TTA.aaaj | 2. modul tesztelése |  | 8d | 2009-02-16 | 2009-02-26 | 21 | 2d | 0d | Á adminisztrátor 3; Á adminisztrátor 4; Á műszaki informatikus 2 | 192h | 384,000 | 480 | 8 n |
| 31 | S2-2008-TTA.aaak | 3. modul tesztelése |  | 6d | 2009-02-09 | 2009-02-17 | 22 | 9d | 0d | Á adminisztrátor 1; Á adminisztrátor 2; Á műszaki informatikus 1 | 144h | 288,000 | 480 | 6 n |
| 32 | S2-2008-TTA.aaaa | modultesztelés kész | milestone | 0d | 2009-02-26 | 2009-02-26 | 29, 30, 31 | 2d |  |  |  |  | 480 | --mérföldkő-- |
| 33 | S2-2008-TTA.aaao | főmodul tesztelése |  | 10d | 2009-03-02 | 2009-03-16 | 32, 24 | 0d |  | Á adminisztrátor 1; Á adminisztrátor 2; Á adminisztrátor 3; Á adminisztrátor 4; Á műszaki informatikus 1; Á műszaki informatikus 2 | 480h | 960,000 | 480 | 10 n |
| 34 | S2-2008-TTA.aaaq | tesztelés kész | milestone | 0d | 2009-03-16 | 2009-03-16 | 33 | 33.5d |  |  |  |  | 480 | --mérföldkő-- |
| 35 | S2-2008-TTB | **kódpontosítás** |  | 22d | 2009-02-17 | 2009-03-19 |  | 0d |  |  | 72h | 324,000 | 480 | 22 n |
| 36 | S2-2008-TTB.aaaa | 1. modul kódpontosítás |  | 2d | 2009-02-25 | 2009-02-27 | 29 | 14d |  | Á programozó 1 | 16h | 72,000 | 480 | 2 n |
| 37 | S2-2008-TTB.aaab | 2. modul kódpontosítás |  | 2d | 2009-02-26 | 2009-03-02 | 30 | 13d |  | Á programozó 2 | 16h | 72,000 | 480 | 2 n |
| 38 | S2-2008-TTB.aaac | 3. modul kódpontosítás |  | 2d | 2009-02-17 | 2009-02-19 | 31 | 20d |  | Á programozó 3 | 16h | 72,000 | 480 | 2 n |
| 39 | S2-2008-TTB.aaae | főmodul kódpontosítás |  | 3d | 2009-03-16 | 2009-03-19 | 33 | 0d |  | Á programozó 1 | 24h | 108,000 | 480 | 3 n |
| 40 | S2-2008-TTB.aaaf | kódpontosítás kész | milestone | 0d | 2009-03-19 | 2009-03-19 | 36, 37, 38, 39 | 0d |  |  |  |  | 480 | --mérföldkő-- |
| 41 | S2-2008-TTH | **Szoftver bevezetése** |  | 48d | 2009-01-13 | 2009-03-19 |  | 0d |  |  | 12h | 44,000 | 480 | 48 n |
| 42 | S2-2008-TTH.aaaa | eredmények bemutatása |  | 4h | 2009-03-19 | 2009-03-19 | 40 | 0d |  | Á programozó 1; Á adatbázistervező 1; Á műszaki informatikus 1 | 12h | 44,000 | 480 | 4 ó |
| 43 | S2-2008-TTH.aaac | döntés a továbblépésről | milestone | 0d | 2009-01-13 | 2009-01-13 |  | 48d |  |  |  |  | 480 | --mérföldkő-- |
| 44 | S2-2008-TTJ | szoftver bevezetése |  | 30d | 2009-03-20 | 2009-04-30 | 42, 43 | 0d |  |  |  |  | 480 | 30 n |
